# Office Remodel

Schedule from MS Project, 2013-01-02 to 2013-03-11, status date 2013-03-12, costs in $, A marks actual dates.
Workspace
DCF

## Calendars

- Standard: Mon-Fri 08:00-12:00, 13:00-17:00; Sat-Sun off.

## Resources

| Resource | Group | Rate | Notes |
| --- | --- | --- | --- |
| Vice President | management | 38.46 |  |
| Office Manager | management | 25 |  |
| Administrative Assistant | office staff | 14.42 |  |
| Operations Manager | management | 21.63 |  |
| Space Planner | contract | 40 |  |
| Maintenance | maintenance | 16 | The cost rate table B is for construction cleaning tasks. |
| Contractor | contract |  |  |
| Mover | contract | 25 |  |
| Electrician | contract |  |  |
| Supervisor | office staff | 16.83 |  |

## Schedule

| ID | WBS | Task | Type | Duration | Start | Finish | Predecessors | Complete | Remaining | Baseline start | Baseline finish | Baseline duration | Total slack | Free slack | Constraint | Resources | Work | Cost | Baseline cost |
| --- | --- | --- | --- | --- | --- | --- | --- | --- | --- | --- | --- | --- | --- | --- | --- | --- | --- | --- | --- |
| 1 | 1 | **Office Workspace Remodel** |  | 48d | 2013-01-02 A | 2013-03-11 |  |  | 48d | 2003-06-04 | 2003-07-17 | 31.5d | 0d |  |  |  | 718h | 24,904.46 | 25,107.15 |
| 2 | 1.1 | **Space planning** |  | 11d | 2013-01-02 A | 2013-01-17 |  |  | 11d | 2003-06-04 | 2003-06-19 | 12d | 37d |  |  |  | 208h | 5,931.54 | 6,227.69 |
| 3 | 1.1.1 | Interview space planners |  | 0.8w | 2013-01-02 | 2013-01-07 |  |  |  | 2005-06-01 | 2005-06-05 | 1w | 27.5d | 0d | start no earlier than 2013-01-02 | Operations Manager; Office Manager; Vice President [25%] | 72h | 1,800 | 2,096.15 |
| 4 | 1.1.2 | Hire space planner |  | 1d | 2013-01-08 | 2013-01-08 | 3 |  |  | 2005-06-08 | 2005-06-08 | 1d | 27.5d | 0d |  | Vice President; Administrative Assistant | 16h | 423.08 | 423.08 |
| 5 | 1.1.3 | Meeting w/space planner |  | 3d | 2013-01-09 | 2013-01-11 | 4 |  |  | 2005-06-09 | 2005-06-11 | 3d | 27.5d | 0d |  | Vice President; Administrative Assistant; Operations Manager; Space Planner | 96h | 2,748.46 | 2,748.46 |
| 6 | 1.1.4 | Finalize space plan |  | 3d | 2013-01-14 | 2013-01-16 | 5 |  |  | 2005-06-12 | 2005-06-16 | 3d | 37d |  |  | Space Planner | 24h | 960 | 960 |
| 7 | 1.1.5 | Space plan complete | milestone | 0d | 2013-01-17 A | 2013-01-17 A | 6 | 100% |  | 2005-06-16 | 2005-06-16 | 0d |  |  |  |  |  |  |  |
| 8 | 1.2 | **Furniture selection** |  | 40d | 2013-01-14 | 2013-03-11 |  |  |  | 2003-06-15 | 2003-07-02 | 11.5d | 0d |  |  |  | 68h | 1,407.69 | 1,407.69 |
| 9 | 1.2.1 | Preview furniture selections |  | 2.5d | 2013-01-14 | 2013-01-16 | 5 |  |  | 2005-06-12 | 2005-06-15 | 2d | 27.5d | 0d |  | Office Manager; Operations Manager; Administrative Assistant | 48h | 976.92 | 976.92 |
| 10 | 1.2.2 | Select new furniture |  | 2d | 2013-01-16 | 2013-01-18 | 9 |  |  | 2005-06-16 | 2005-06-17 | 1.5d | 27.5d | 0d |  | Office Manager [75%]; Operations Manager | 16h | 373.08 | 373.08 |
| 11 | 1.2.3 | Order new furniture |  | 0.5d | 2013-01-18 | 2013-01-18 | 10 |  |  | 2005-06-17 | 2005-06-17 | 0.5d | 27.5d |  |  | Administrative Assistant | 4h | 57.69 | 57.69 |
| 12 | 1.2.4 | Furniture delivered | milestone | 0d | 2013-03-11 | 2013-03-11 | 11FS+1.5w |  |  | 2005-06-29 | 2005-06-29 | 0d | 0d |  | start no earlier than 2013-03-11 |  |  |  |  |
| 13 | 1.3 | **Remodel workspace** |  | 14d | 2013-01-17 | 2013-02-05 |  |  |  | 2003-06-20 | 2003-07-09 | 14d | 18d |  |  |  | 304h | 14,423.08 | 14,423.08 |
| 14 | 1.3.1 | Hire contractor |  | 4d | 2013-01-17 | 2013-01-22 | 7 |  |  | 2005-06-17 | 2005-06-22 | 4d | 18d | 0d |  | Vice President; Operations Manager | 64h | 1,923.08 | 1,923.08 |
| 15 | 1.3.2 | Remodel workspace |  | 2w | 2013-01-23 | 2013-02-05 | 14 |  |  | 2005-06-23 | 2005-07-06 | 2w | 18d | 0d |  | Contractor [200%]; Electrician | 240h | 12,500 | 12,500 |
| 16 | 1.3.3 | Remodel complete | milestone | 0d | 2013-02-05 | 2013-02-05 | 15 |  |  | 2005-07-06 | 2005-07-06 | 0d | 23d |  |  |  |  |  |  |
| 17 | 1.4 | **New workspace** |  | 18d | 2013-01-17 | 2013-02-11 |  |  |  | 2003-06-20 | 2003-07-17 | 19.5d | 19d | 0d |  |  | 138h | 3,142.15 | 3,048.69 |
| 18 | 1.4.1 | Hire mover |  | 4d | 2013-01-17 | 2013-01-22 | 14SS |  |  | 2005-06-17 | 2005-06-22 | 4d | 25d | 0d |  | Supervisor | 32h | 538.46 | 538.46 |
| 19 | 1.4.2 | Pack workspace |  | 1d | 2013-01-23 | 2013-01-23 | 18, 14 |  |  | 2005-06-23 | 2005-06-23 | 1d | 25d | 0d |  | Administrative Assistant; Supervisor | 16h | 250 | 250 |
| 20 | 1.4.3 | Move Equipment |  | 0.5d | 2013-01-23 | 2013-01-23 | 19FF |  |  | 2005-06-23 | 2005-06-23 | 0.5d | 25d | 0d |  | Mover; Operations Manager | 8h | 186.54 | 186.54 |
| 21 | 1.4.4 | Remove existing furniture |  | 2d | 2013-01-24 | 2013-01-25 | 20 |  |  | 2005-07-03 | 2005-07-03 | 1d | 25d | 7d |  | Mover | 16h | 400 | 200 |
| 22 | 1.4.5 | Assemble new furniture |  | 2d | 2013-02-06 | 2013-02-07 | 21, 15 |  |  | 2005-07-07 | 2005-07-08 | 2d | 18d | 0d | finish no earlier than 2013-02-07 | Supervisor; Space Planner | 34h | 1,069.23 | 989.23 |
| 23 | 1.4.6 | Return equipment |  | 0.5d | 2013-02-07 | 2013-02-07 | 22FS-0.5d |  |  | 2005-07-08 | 2005-07-09 | 1d | 18d | 0d | finish no earlier than 2013-02-07 | Mover; Operations Manager | 8h | 186.54 | 373.08 |
| 24 | 1.4.7 | Unpack workspace |  | 1d | 2013-02-08 | 2013-02-08 | 23 |  |  | 2005-07-09 | 2005-07-10 | 1d | 18d | 0d |  | Mover; Administrative Assistant | 16h | 315.38 | 315.38 |
| 25 | 1.4.8 | Workspace final clean |  | 1d | 2013-02-11 | 2013-02-11 | 24 |  |  | 2005-07-10 | 2005-07-14 | 2d | 18d |  |  | Maintenance [50%]; Mover [50%] | 8h | 196 | 196 |
| 26 | 1.5 | Workspace remodel complete | milestone | 0d | 2013-02-11 | 2013-02-11 | 17 |  |  | 2005-07-14 | 2005-07-14 | 0d | 19d |  | start no earlier than 2013-02-11 |  |  |  |  |

Notes:
- 11: Allow 1.5 weeks for delivery.
