# 2011 Shareholder Meeting

Schedule from MS Project, 2013-06-03 to 2013-07-16.

## Calendars

- Standard: Mon-Fri 08:00-12:00, 13:00-17:00; Sat-Sun off.

## Resources

| Resource | Group |
| --- | --- |
| Pat Kelly | management |
| Leslie Mitchell | management |
| Sam Merris | office staff |
| Terry Johnstone | office staff |
| Alex Patterson | management |

## Schedule

| ID | WBS | Task | Type | Duration | Start | Finish | Predecessors | Total slack | Free slack | Constraint | Resources | Work |
| --- | --- | --- | --- | --- | --- | --- | --- | --- | --- | --- | --- | --- |
| 1 | 1 | **Shareholders Meeting** |  | 32d | 2013-06-03 | 2013-07-16 |  | 0d |  |  |  | 443h |
| 2 | 1.1 | **Plan meeting** |  | 13.5d | 2013-06-03 | 2013-06-20 |  | 1.12d |  |  |  | 208h |
| 3 | 1.1.1 | **Preliminary planning** |  | 13.5d | 2013-06-03 | 2013-06-20 |  | 1.12d | 0d |  |  | 208h |
| 4 | 1.1.1.1 | Schedule conference date |  | 2d | 2013-06-03 | 2013-06-04 |  | 1.12d | 0d |  | Pat Kelly; Leslie Mitchell | 32h |
| 5 | 1.1.1.2 | Book conference center |  | 2d | 2013-06-05 | 2013-06-06 | 4 | 1.12d | 0d |  | Sam Merris | 16h |
| 6 | 1.1.1.3 | Book keynote speaker |  | 10d | 2013-06-06 | 2013-06-20 | 5FS-0.5d | 1.12d | 0d |  | Leslie Mitchell; Terry Johnstone | 160h |
| 7 | 1.1.1.4 | Preliminary planning complete | milestone | 0d | 2013-06-20 | 2013-06-20 | 6 | 1.12d |  |  |  |  |
| 8 | 1.2 | **Notification letter** |  | 8.88d | 2013-06-20 | 2013-07-03 | 3 | 1.12d |  |  |  | 87h |
| 9 | 1.2.1 | Order letter stock |  | 1h | 2013-06-20 | 2013-06-20 |  | 1.12d | 0d |  | Sam Merris | 1h |
| 10 | 1.2.2 | Develop letter |  | 2d | 2013-06-20 | 2013-06-24 | 9 | 1.12d | 0d |  | Terry Johnstone | 16h |
| 11 | 1.2.3 | Review letter |  | 3.25d | 2013-06-24 | 2013-06-27 | 10 | 1.12d | 0d |  | Leslie Mitchell; Alex Patterson | 52h |
| 12 | 1.2.4 | Approve letter |  | 1d | 2013-06-27 | 2013-06-28 | 11 | 9.62d | 0d |  | Pat Kelly | 8h |
| 13 | 1.2.5 | Print letter |  | 2.5d | 2013-06-28 | 2013-07-03 | 12 | 9.62d | 0d |  | Sam Merris [50%] | 10h |
| 14 | 1.2.6 | Send letter | milestone | 0d | 2013-07-03 | 2013-07-03 | 13 | 9.62d |  |  |  |  |
| 15 | 1.3 | **Meeting details** |  | 11d | 2013-06-27 | 2013-07-12 | 3 | 1.12d |  |  |  | 148h |
| 16 | 1.3.1 | Plan food with caterer |  | 4.62d | 2013-06-27 | 2013-07-04 | 11 | 1.12d | 0d |  | Terry Johnstone; Leslie Mitchell | 74h |
| 17 | 1.3.2 | Arrange committee meeting rooms |  | 0.5d | 2013-06-27 | 2013-06-28 | 16SS | 1.12d | 0d |  | Sam Merris | 4h |
| 18 | 1.3.3 | Arrange necessary equipment |  | 1.5d | 2013-06-28 | 2013-07-01 | 17 | 1.12d | 0d |  | Sam Merris | 12h |
| 19 | 1.3.4 | Create agenda |  | 3.5d | 2013-07-01 | 2013-07-05 | 18 | 1.12d | 0d |  | Sam Merris [50%] | 14h |
| 20 | 1.3.5 | Print agenda |  | 5.5d | 2013-07-05 | 2013-07-12 | 19 | 1.12d | 0d |  | Sam Merris | 44h |
| 21 | 1.3.6 | Meeting Details Complete | milestone | 0d | 2013-07-12 | 2013-07-12 | 20 | 2.12d |  |  |  |  |
| 22 | 1.4 | Meeting occurs! |  | 1d | 2013-07-16 | 2013-07-16 | 2FS+2d, 16, 17, 18, 20 | 0d |  | must finish on 2013-07-16 |  |  |

Notes:
- 22: A Must Finish On constraint should be set for the day of the meeting.
