# Office Remodel

Schedule from MS Project, 2013-01-09 to 2013-07-15, status date 2013-01-21, costs in $, A marks actual dates.
Workspace
DCF

## Calendars

- Standard: Mon-Fri 08:00-12:00, 13:00-17:00; Sat-Sun off.

## Resources

| Resource | Group | Rate | Notes |
| --- | --- | --- | --- |
| Vice President | management | 38.46 |  |
| Office Manager | management | 25 |  |
| Administrative Assistant | office staff | 14.42 |  |
| Operations Manager | management | 21.63 |  |
| Space Planner | contract | 40 |  |
| Maintenance | maintenance | 16 | The cost rate table B is for construction cleaning tasks. |
| Contractor | contract |  |  |
| Mover | contract | 25 |  |
| Electrician | contract |  |  |
| Supervisor | office staff | 16.83 |  |

## Schedule

| ID | WBS | Task | Type | Duration | Start | Finish | Predecessors | Complete | Remaining | Baseline start | Baseline finish | Baseline duration | Total slack | Free slack | Constraint | Resources | Work | Actual work | Cost | Baseline cost | Actual cost |
| --- | --- | --- | --- | --- | --- | --- | --- | --- | --- | --- | --- | --- | --- | --- | --- | --- | --- | --- | --- | --- | --- |
| 1 | 1 | **Office Workspace Remodel** |  | 133d | 2013-01-09 A | 2013-07-15 |  | 76% | 31.67d | 2013-01-02 | 2013-07-24 | 145.5d | 0d |  |  |  | 729h | 572h | 25,174.08 | 25,174.08 | 10,048.46 |
| 2 | 1.1 | **Space planning** |  | 12d | 2013-01-09 A | 2013-01-24 |  | 91% | 1.04d | 2013-01-02 | 2013-01-17 | 12d | 121d |  |  |  | 200h | 192h | 5,793.46 | 5,793.46 | 5,473.46 |
| 3 | 1.1.1 | Interview space planners |  | 0.8w | 2013-01-09 A | 2013-01-14 A |  | 100% |  | 2013-01-02 | 2013-01-07 | 0.8w |  |  | start no earlier than 2013-01-09 | Operations Manager; Office Manager; Vice President [25%] | 72h | 72h | 1,800 | 1,800 | 1,800 |
| 4 | 1.1.2 | Hire space planner |  | 1d | 2013-01-15 A | 2013-01-15 A | 3 | 100% |  | 2013-01-08 | 2013-01-08 | 1d |  |  |  | Vice President; Administrative Assistant | 16h | 16h | 423.08 | 423.08 | 423.08 |
| 5 | 1.1.3 | Meeting w/space planner |  | 2.5d | 2013-01-16 A | 2013-01-18 A | 4 | 100% |  | 2013-01-09 | 2013-01-11 | 2.5d |  |  |  | Vice President; Administrative Assistant; Operations Manager; Space Planner | 80h | 80h | 2,290.38 | 2,290.38 | 2,290.38 |
| 6 | 1.1.4 | Finalize space plan |  | 4d | 2013-01-21 A | 2013-01-24 | 5 | 75% | 1d | 2013-01-14 | 2013-01-17 | 4d | 121d |  |  | Space Planner | 32h | 24h | 1,280 | 1,280 | 960 |
| 7 | 1.2 | **Furniture selection** |  | 13.38d | 2013-01-21 A | 2013-02-07 |  | 94% | 0.85d | 2013-01-14 | 2013-01-31 | 13.38d | 111.62d |  |  |  | 75h | 72h | 1,508.65 | 1,508.65 | 1,465.38 |
| 8 | 1.2.1 | Preview furniture selections |  | 2.5d | 2013-01-21 A | 2013-01-23 A | 5 | 100% |  | 2013-01-14 | 2013-01-16 | 2.5d |  |  |  | Office Manager; Operations Manager; Administrative Assistant | 48h | 48h | 976.92 | 976.92 | 976.92 |
| 9 | 1.2.2 | Select new furniture |  | 2d | 2013-01-23 A | 2013-01-25 A | 8 | 100% |  | 2013-01-16 | 2013-01-18 | 2d |  |  |  | Office Manager [75%]; Operations Manager | 16h | 16h | 373.08 | 373.08 | 373.08 |
| 10 | 1.2.3 | Order new furniture |  | 1.38d | 2013-01-25 A | 2013-01-28 | 9 | 73% | 0.38d | 2013-01-18 | 2013-01-21 | 1.38d | 111.62d | 0d |  | Administrative Assistant | 11h | 8h | 158.65 | 158.65 | 115.38 |
| 11 | 1.2.4 | Furniture delivered | milestone | 0d | 2013-02-07 | 2013-02-07 | 10FS+1.5w |  |  | 2013-01-31 | 2013-01-31 | 0d | 111.62d |  |  |  |  |  |  |  |  |
| 12 | 1.3 | **Remodel workspace** |  | 13.5d | 2013-01-24 A | 2013-02-12 |  | 77% | 3.08d | 2013-01-17 | 2013-02-05 | 13.5d | 108.5d |  |  |  | 308h | 236h | 14,543.27 | 14,543.27 | 1,682.69 |
| 13 | 1.3.1 | Hire contractor |  | 4.25d | 2013-01-24 A | 2013-01-30 |  | 82% | 0.75d | 2013-01-17 | 2013-01-23 | 4.25d | 6.75d | 0d |  | Vice President; Operations Manager | 68h | 56h | 2,043.27 | 2,043.27 | 1,682.69 |
| 14 | 1.3.2 | Remodel workspace |  | 2w | 2013-01-29 A | 2013-02-12 | 13 | 75% | 0.5w | 2013-01-22 | 2013-02-05 | 2w | 103.5d | 0d |  | Contractor [200%]; Electrician | 240h | 180h | 12,500 | 12,500 |  |
| 15 | 1.3.3 | Remodel complete | milestone | 0d | 2013-02-12 | 2013-02-12 | 14 |  |  | 2013-02-05 | 2013-02-05 | 0d | 108.5d |  |  |  |  |  |  |  |  |
| 16 | 1.4 | **New workspace** |  | 120.5d | 2013-01-24 A | 2013-07-11 |  | 54% | 55.62d | 2013-01-17 | 2013-07-24 | 134.5d | 1.5d |  |  |  | 146h | 72h | 3,328.69 | 3,328.69 | 1,426.92 |
| 17 | 1.4.1 | Hire mover |  | 4d | 2013-01-24 A | 2013-01-29 | 13SS | 75% | 1d | 2013-01-17 | 2013-01-22 | 4d | 118d |  |  | Supervisor | 32h | 24h | 538.46 | 538.46 | 403.85 |
| 18 | 1.4.2 | Pack workspace |  | 1d | 2013-01-30 A | 2013-01-30 A | 17, 13 | 100% |  | 2013-01-23 | 2013-01-23 | 1d |  |  |  | Administrative Assistant; Supervisor | 16h | 16h | 250 | 250 | 250 |
| 19 | 1.4.3 | Move Equipment |  | 1d | 2013-01-30 A | 2013-01-31 A | 18FF | 100% |  | 2013-01-23 | 2013-01-24 | 1d |  |  |  | Mover; Operations Manager | 16h | 16h | 373.08 | 373.08 | 373.08 |
| 20 | 1.4.4 | Remove existing furniture |  | 2d | 2013-01-31 A | 2013-02-04 A | 19 | 100% |  | 2013-01-24 | 2013-01-28 | 2d |  |  |  | Mover | 16h | 16h | 400 | 400 | 400 |
| 21 | 1.4.5 | Assemble new furniture |  | 2d | 2013-07-05 | 2013-07-08 | 20, 14 |  |  | 2013-07-18 | 2013-07-19 | 2d | 1d | 0d | finish no earlier than 2013-07-08 | Supervisor; Space Planner | 34h |  | 1,069.23 | 1,069.23 |  |
| 22 | 1.4.6 | Return equipment |  | 0.5d | 2013-07-08 | 2013-07-08 | 21FS-0.5d |  |  | 2013-07-19 | 2013-07-19 | 0.5d | 1d | 0d | finish no earlier than 2013-07-08 | Mover; Operations Manager | 8h |  | 186.54 | 186.54 |  |
| 23 | 1.4.7 | Unpack workspace |  | 1d | 2013-07-09 | 2013-07-09 | 22 |  |  | 2013-07-22 | 2013-07-22 | 1d | 1d | 0d |  | Mover; Administrative Assistant | 16h |  | 315.38 | 315.38 |  |
| 24 | 1.4.8 | Workspace final clean |  | 1.5d | 2013-07-10 | 2013-07-11 | 23 |  |  | 2013-07-23 | 2013-07-24 | 1.5d | 1d |  |  | Maintenance [50%]; Mover [50%] | 8h |  | 196 | 196 |  |
| 25 | 1.5 | Workspace remodel complete | milestone | 0d | 2013-07-15 | 2013-07-15 | 16 |  |  | 2013-07-24 | 2013-07-24 | 0d | 0d |  | start no earlier than 2013-07-15 |  |  |  |  |  |  |

Notes:
- 10: Allow 1.5 weeks for delivery.
