# Company Conference

Schedule from MS Project, 2013-01-04 to 2013-02-08.
Company Conference
DCF

## Calendars

- Standard: Mon-Fri 08:00-12:00, 13:00-17:00; Sat-Sun off.

## Resources

| Resource | Group |
| --- | --- |
| office manager | management |
| vice president | management |
| administrative assistant | office staff |
| intern | temp |
| caterer | outside service |
| technicians | outside service |
| printer | outside service |

## Schedule

| ID | WBS | Task | Type | Duration | Start | Finish | Predecessors | Baseline start | Baseline finish | Baseline duration | Total slack | Free slack | Resources | Work |
| --- | --- | --- | --- | --- | --- | --- | --- | --- | --- | --- | --- | --- | --- | --- |
| 1 | 1 | **Company Conference** |  | 25.62d | 2013-01-04 | 2013-02-08 |  | 2011-07-01 | 2011-08-05 | 25.62d | 0d |  |  | 560h |
| 2 | 1.1 | **Conference site** |  | 8d | 2013-01-04 | 2013-01-15 |  | 2011-07-01 | 2011-07-12 | 8d | 17.62d |  |  | 160h |
| 3 | 1.1.1 | Identify possible sites |  | 3d | 2013-01-04 | 2013-01-08 |  | 2011-07-01 | 2011-07-05 | 3d | 17.62d | 0d | administrative assistant | 24h |
| 4 | 1.1.2 | Visit sites |  | 1w | 2013-01-07 | 2013-01-11 | 3FS-2d | 2011-07-04 | 2011-07-08 | 1w | 17.62d | 0d | office manager; vice president; administrative assistant | 120h |
| 5 | 1.1.3 | Select site |  | 2d | 2013-01-14 | 2013-01-15 | 4 | 2011-07-11 | 2011-07-12 | 2d | 17.62d | 0d | office manager | 16h |
| 6 | 1.1.4 | Site selected | milestone | 0d | 2013-01-15 | 2013-01-15 | 5 | 2011-07-12 | 2011-07-12 | 0d | 17.62d |  |  |  |
| 7 | 1.2 | **Invitations** |  | 19.62d | 2013-01-04 | 2013-01-31 |  | 2011-07-01 | 2011-07-28 | 19.62d | 0d |  |  | 128h |
| 8 | 1.2.1 | Draft invitations |  | 1d | 2013-01-04 | 2013-01-04 |  | 2011-07-01 | 2011-07-01 | 1d | 0d |  | administrative assistant; intern | 16h |
| 9 | 1.2.2 | Print invitations |  | 1w | 2013-01-07 | 2013-01-11 | 8 | 2011-07-04 | 2011-07-08 | 1w | 0d |  | printer | 40h |
| 10 | 1.2.3 | Address invitations |  | 1w | 2013-01-14 | 2013-01-18 | 9 | 2011-07-11 | 2011-07-15 | 1w | 0d |  | intern | 40h |
| 11 | 1.2.4 | Send invitations |  | 2d | 2013-01-21 | 2013-01-22 | 10 | 2011-07-18 | 2011-07-19 | 2d | 0d |  | administrative assistant | 16h |
| 12 | 1.2.5 | Receive RSVPs |  | 1.5w | 2013-01-22 | 2013-01-31 | 11FS-1d | 2011-07-19 | 2011-07-28 | 1.5w | 0d |  | intern [25%] | 15h |
| 13 | 1.2.6 | Final count to caterer |  | 1h | 2013-01-31 | 2013-01-31 | 12 | 2011-07-28 | 2011-07-28 | 1h | 0d |  | administrative assistant | 1h |
| 14 | 1.2.7 | Invitations completed | milestone | 0d | 2013-01-31 | 2013-01-31 | 13 | 2011-07-28 | 2011-07-28 | 0d | 6d |  |  |  |
| 15 | 1.3 | **Food** |  | 18.62d | 2013-01-07 | 2013-01-31 |  | 2011-07-04 | 2011-07-28 | 18.62d | 0d |  |  | 160h |
| 16 | 1.3.1 | Interview caterers |  | 4d | 2013-01-07 | 2013-01-10 | 8SS+1d | 2011-07-04 | 2011-07-07 | 4d | 6.62d | 0d | vice president; office manager; administrative assistant | 96h |
| 17 | 1.3.2 | Hire caterer |  | 1d | 2013-01-14 | 2013-01-14 | 16FS+2.5% | 2011-07-11 | 2011-07-11 | 1d | 6.62d | 0d | office manager | 8h |
| 18 | 1.3.3 | Taste sample food |  | 1d | 2013-01-18 | 2013-01-18 | 17FS+3d | 2011-07-15 | 2011-07-15 | 1d | 6.62d | 0d | administrative assistant; caterer; office manager | 24h |
| 19 | 1.3.4 | Select final menu |  | 2d | 2013-01-21 | 2013-01-22 | 18 | 2011-07-18 | 2011-07-19 | 2d | 6.62d |  | office manager; administrative assistant | 32h |
| 20 | 1.3.5 | Food preparation complete | milestone | 0d | 2013-01-31 | 2013-01-31 | 19, 13 | 2011-07-28 | 2011-07-28 | 0d | 0d |  |  |  |
| 21 | 1.4 | **Speaker** |  | 5d | 2013-01-31 | 2013-02-07 | 15 | 2011-07-28 | 2011-08-04 | 5d | 0d |  |  | 112h |
| 22 | 1.4.1 | Interview speakers |  | 4d | 2013-01-31 | 2013-02-06 |  | 2011-07-28 | 2011-08-03 | 4d | 0d |  | office manager; administrative assistant; vice president | 96h |
| 23 | 1.4.2 | Hire keynote speaker |  | 0.5d | 2013-02-06 | 2013-02-07 | 22 | 2011-08-03 | 2011-08-04 | 0.5d | 0d |  | administrative assistant; office manager | 8h |
| 24 | 1.4.3 | Hire workshop facilitator |  | 0.5d | 2013-02-07 | 2013-02-07 | 23 | 2011-08-04 | 2011-08-04 | 0.5d | 0d |  | administrative assistant; office manager | 8h |
| 25 | 1.4.5 | Speakers selected | milestone | 0d | 2013-02-07 | 2013-02-07 | 24 | 2011-08-04 | 2011-08-04 | 0d | 0d |  |  |  |
| 26 | 1.5 | Day of conference | milestone | 0d | 2013-02-08 | 2013-02-08 | 21FS+1d | 2011-08-05 | 2011-08-05 | 0d | 0d |  |  |  |
