# Office Remodel

Schedule from MS Project, 2013-01-02 to 2013-02-13, status date 2013-01-29, costs in $, A marks actual dates.
Workspace
DCF

## Calendars

- Standard: Mon-Fri 08:00-12:00, 13:00-17:00; Sat-Sun off.

## Resources

| Resource | Group | Rate | Notes |
| --- | --- | --- | --- |
| Vice President | management | 38.46 |  |
| Office Manager | management | 25 |  |
| Administrative Assistant | office staff | 14.42 |  |
| Operations Manager | management | 21.63 |  |
| Space Planner | contract | 40 |  |
| Maintenance | maintenance | 16 | The cost rate table B is for construction cleaning tasks. |
| Contractor | contract |  |  |
| Mover | contract | 25 |  |
| Electrician | contract |  |  |
| Supervisor | office staff | 16.83 |  |

## Schedule

| ID | WBS | Task | Type | Duration | Start | Finish | Predecessors | Complete | Remaining | Baseline start | Baseline finish | Baseline duration | Total slack | Free slack | Constraint | Resources | Work | Cost | Baseline cost |
| --- | --- | --- | --- | --- | --- | --- | --- | --- | --- | --- | --- | --- | --- | --- | --- | --- | --- | --- | --- |
| 1 | 1 | **Office Workspace Remodel** |  | 31d | 2013-01-02 A | 2013-02-13 |  |  | 31d | 2011-06-07 | 2011-07-14 | 27.5d | 117.12d |  |  |  | 692h | 24,856.46 | 24,856.46 |
| 2 | 1.1 | **Space planning** |  | 11d | 2013-01-02 A | 2013-01-17 |  |  | 11d | 2011-06-07 | 2011-06-22 | 11d | 137.12d |  |  |  | 208h | 5,931.54 | 5,931.54 |
| 3 | 1.1.1 | Interview space planners |  | 0.8w | 2013-01-02 | 2013-01-07 |  |  |  | 2011-06-07 | 2011-06-10 | 0.8w | 127.62d | 0d |  | Operations Manager; Office Manager; Vice President [25%] | 72h | 1,800 | 1,800 |
| 4 | 1.1.2 | Hire space planner |  | 1d | 2013-01-08 | 2013-01-08 | 3 |  |  | 2011-06-13 | 2011-06-13 | 1d | 127.62d | 0d |  | Vice President; Administrative Assistant | 16h | 423.08 | 423.08 |
| 5 | 1.1.3 | Meeting w/space planner |  | 3d | 2013-01-09 | 2013-01-11 | 4 |  |  | 2011-06-14 | 2011-06-16 | 3d | 127.62d | 0d |  | Vice President; Administrative Assistant; Operations Manager; Space Planner | 96h | 2,748.46 | 2,748.46 |
| 6 | 1.1.4 | Finalize space plan |  | 3d | 2013-01-14 | 2013-01-16 | 5 |  |  | 2011-06-17 | 2011-06-21 | 3d | 137.12d |  |  | Space Planner | 24h | 960 | 960 |
| 7 | 1.1.5 | Space plan complete | milestone | 0d | 2013-01-17 A | 2013-01-17 A | 6 | 100% |  | 2011-06-22 | 2011-06-22 | 0d |  |  |  |  |  |  |  |
| 8 | 1.2 | **Furniture selection** |  | 13d | 2013-01-14 | 2013-01-31 |  |  |  | 2011-06-17 | 2011-07-06 | 13d | 127.12d |  |  |  | 68h | 1,407.69 | 1,407.69 |
| 9 | 1.2.1 | Preview furniture selections |  | 2.5d | 2013-01-14 | 2013-01-16 | 5 |  |  | 2011-06-17 | 2011-06-21 | 2.5d | 127.62d | 0d |  | Office Manager; Operations Manager; Administrative Assistant | 48h | 976.92 | 976.92 |
| 10 | 1.2.2 | Select new furniture |  | 2d | 2013-01-16 | 2013-01-18 | 9 |  |  | 2011-06-21 | 2011-06-23 | 2d | 127.62d | 0d |  | Office Manager [75%]; Operations Manager | 16h | 373.08 | 373.08 |
| 11 | 1.2.3 | Order new furniture |  | 0.5d | 2013-01-18 | 2013-01-18 | 10 |  |  | 2011-06-23 | 2011-06-23 | 0.5d | 127.62d | 0.5d |  | Administrative Assistant | 4h | 57.69 | 57.69 |
| 12 | 1.2.4 | Furniture delivered | milestone | 0d | 2013-01-31 | 2013-01-31 | 11FS+1.5w |  |  | 2011-07-06 | 2011-07-06 | 0d | 127.12d |  | start no earlier than 2013-01-31 |  |  |  |  |
| 13 | 1.3 | **Remodel workspace** |  | 13d | 2013-01-17 | 2013-02-04 |  |  |  | 2011-06-22 | 2011-07-08 | 13d | 3.5d |  |  |  | 280h | 14,423.08 | 14,423.08 |
| 14 | 1.3.1 | Hire contractor |  | 4d | 2013-01-17 | 2013-01-22 | 7 |  |  | 2011-06-22 | 2011-06-27 | 4d | 3.5d | 0d |  | Vice President; Operations Manager | 64h | 1,923.08 | 1,923.08 |
| 15 | 1.3.2 | Remodel workspace |  | 9d | 2013-01-23 | 2013-02-04 | 14 |  |  | 2011-06-28 | 2011-07-08 | 9d | 3.5d | 0d |  | Contractor [200%]; Electrician | 216h | 12,500 | 12,500 |
| 16 | 1.3.3 | Remodel complete | milestone | 0d | 2013-02-04 | 2013-02-04 | 15 |  |  | 2011-07-08 | 2011-07-08 | 0d | 58.88d | 0d |  |  |  |  |  |
| 17 | 1.1.2 | Draft invitations |  | 1d | 2013-02-05 | 2013-02-05 | 16 |  |  |  |  |  | 58.88d |  |  |  | 16h |  |  |
| 18 | 1.4 | **New workspace** |  | 20d | 2013-01-17 | 2013-02-13 |  |  |  | 2011-06-22 | 2011-07-14 | 16.5d | 0d |  |  |  | 136h | 3,094.15 | 3,094.15 |
| 19 | 1.4.1 | Hire mover |  | 4d | 2013-01-17 | 2013-01-22 | 14SS |  |  | 2011-06-22 | 2011-06-27 | 4d | 9.5d | 0d |  | Supervisor | 32h | 538.46 | 538.46 |
| 20 | 1.4.2 | Pack workspace |  | 1d | 2013-01-23 | 2013-01-23 | 19, 14 |  |  | 2011-06-28 | 2011-06-28 | 1d | 9.5d | 0d |  | Administrative Assistant; Supervisor | 16h | 250 | 250 |
| 21 | 1.4.3 | Move Equipment |  | 0.5d | 2013-01-23 | 2013-01-23 | 20FF |  |  | 2011-06-28 | 2011-06-28 | 0.5d | 9.5d |  |  | Mover; Operations Manager | 8h | 186.54 | 186.54 |
| 22 | 1.4.4 | Remove existing furniture |  | 2d | 2013-02-06 | 2013-02-08 | 21 |  |  | 2011-07-07 | 2011-07-08 | 2d | 0d |  | as late as possible | Mover | 16h | 400 | 400 |
| 23 | 1.4.5 | Assemble new furniture |  | 2d | 2013-02-08 | 2013-02-12 | 22, 15 |  |  | 2011-07-11 | 2011-07-12 | 2d | 0d |  |  | Supervisor; Space Planner | 34h | 1,069.23 | 1,069.23 |
| 24 | 1.4.6 | Return equipment |  | 0.5d | 2013-02-12 | 2013-02-12 | 23FS-0.5d |  |  | 2011-07-12 | 2011-07-12 | 0.5d | 0d |  |  | Mover; Operations Manager | 8h | 186.54 | 186.54 |
| 25 | 1.4.7 | Unpack workspace |  | 1d | 2013-02-12 | 2013-02-13 | 24 |  |  | 2011-07-13 | 2011-07-13 | 1d | 0d |  |  | Mover; Administrative Assistant | 16h | 315.38 | 315.38 |
| 26 | 1.4.8 | Workspace final clean |  | 1d | 2013-02-13 | 2013-02-13 | 25FS-0.5d |  |  | 2011-07-13 | 2011-07-14 | 1d | 0d |  |  | Maintenance [50%]; Mover [50%] | 6h | 148 | 148 |
| 27 | 1.5 | Workspace remodel complete | milestone | 0d | 2013-02-13 | 2013-02-13 | 18 |  |  | 2011-07-14 | 2011-07-14 | 0d | 0d |  | finish no later than 2013-02-13 |  |  |  |  |

Notes:
- 11: Allow 1.5 weeks for delivery.
