# 2013 Meeting

Schedule from MS Project, 2013-03-12 to 2013-07-29, status date 2013-07-29, A marks actual dates.
Shareholders Meeting
DCF

## Calendars

- Standard: Mon-Fri 08:00-12:00, 13:00-17:00; Sat-Sun off.

## Resources

| Resource | Group |
| --- | --- |
| vice president | management |
| office manager | management |
| administrative assistant | office staff |
| intern | office staff |
| operations manager | management |

## Schedule

| ID | WBS | Task | Type | Duration | Start | Finish | Predecessors | Complete | Remaining | Baseline start | Baseline finish | Baseline duration | Total slack | Free slack | Resources | Work |
| --- | --- | --- | --- | --- | --- | --- | --- | --- | --- | --- | --- | --- | --- | --- | --- | --- |
| 1 | 1 | **Shareholders Meeting** |  | 39.62d | 2013-06-03 A | 2013-07-29 |  |  | 39.62d | 2011-06-06 | 2011-08-01 | 39.62d | 0d |  |  | 220h |
| 2 | 1.1 | **Plan meeting** |  | 36.62d | 2013-06-03 A | 2013-07-24 |  |  | 36.62d | 2011-06-06 | 2011-07-27 | 36.62d | 0d |  |  | 220h |
| 3 | 1.1.1 | **Preliminary planning** |  | 24d | 2013-06-03 A | 2013-07-05 |  |  | 24d | 2011-06-06 | 2011-07-08 | 24d | 0d |  |  | 108h |
| 4 | 1.4 | Day of conference | milestone | 0d | 2013-03-12 | 2013-03-12 |  |  |  |  |  |  | 58.88d |  |  |  |
| 5 | 1.1.1.2 | Schedule meeting date |  | 1d | 2013-06-03 | 2013-06-04 | 4 |  |  | 2011-06-06 | 2011-06-07 | 1d | 0d |  | vice president; office manager | 16h |
| 6 | 1.1.1.3 | Book conference center |  | 2d | 2013-06-05 | 2013-06-10 | 5 |  |  | 2011-06-08 | 2011-06-13 | 2d | 0d |  | intern | 16h |
| 7 | 1.1.1.4 | Book keynote speaker |  | 10d | 2013-06-10 | 2013-07-05 | 6FS-0.5d |  |  | 2011-06-13 | 2011-07-08 | 10d | 0d |  | office manager; administrative assistant | 76h |
| 8 | 1.1.1.5 | Preliminary planning complete | milestone | 0d | 2013-07-05 A | 2013-07-05 A | 7 | 100% |  | 2011-07-08 | 2011-07-08 | 0d |  |  |  |  |
| 9 | 1.1.2 | **Notification letter** |  | 7.62d | 2013-07-08 | 2013-07-18 | 3 |  |  | 2011-07-11 | 2011-07-21 | 7.62d | 0d |  |  | 36h |
| 10 | 1.1.2.1 | Order letter stock |  | 1h | 2013-07-08 | 2013-07-08 |  |  |  | 2011-07-11 | 2011-07-11 | 1h | 0d |  | intern | 1h |
| 11 | 1.1.2.2 | Develop letter |  | 1d | 2013-07-08 | 2013-07-10 | 10 |  |  | 2011-07-11 | 2011-07-13 | 1d | 0d |  | administrative assistant | 8h |
| 12 | 1.1.2.3 | Review letter |  | 1d | 2013-07-08 | 2013-07-10 | 11SS |  |  | 2011-07-11 | 2011-07-13 | 1d | 0d |  | office manager; operations manager | 11h |
| 13 | 1.1.2.4 | Approve letter |  | 1d | 2013-07-10 | 2013-07-12 | 12 |  |  | 2011-07-13 | 2011-07-15 | 1d | 4d | 0d | vice president | 8h |
| 14 | 1.1.2.5 | Print letter |  | 2d | 2013-07-12 | 2013-07-18 | 13 |  |  | 2011-07-15 | 2011-07-21 | 2d | 4d | 0d | intern [50%] | 8h |
| 15 | 1.1.2.6 | Send letter | milestone | 0d | 2013-07-18 | 2013-07-18 | 14 |  |  | 2011-07-21 | 2011-07-21 | 0d | 4d |  |  |  |
| 16 | 1.1.3 | **Meeting details** |  | 10d | 2013-07-10 | 2013-07-24 | 3 |  |  | 2011-07-13 | 2011-07-27 | 10d | 0d |  |  | 76h |
| 17 | 1.1.3.1 | Plan food with caterer |  | 3d | 2013-07-10 | 2013-07-18 | 12 |  |  | 2011-07-13 | 2011-07-21 | 3d | 0d |  | administrative assistant; office manager | 48h |
| 18 | 1.1.3.2 | Arrange committee meeting rooms |  | 0.5d | 2013-07-10 | 2013-07-11 | 17SS |  |  | 2011-07-13 | 2011-07-14 | 0.5d | 0d |  | intern | 4h |
| 19 | 1.1.3.3 | Arrange necessary equipment |  | 0.5d | 2013-07-11 | 2013-07-12 | 18 |  |  | 2011-07-14 | 2011-07-15 | 0.5d | 0d |  | intern | 4h |
| 20 | 1.1.3.4 | Create agenda |  | 3d | 2013-07-12 | 2013-07-22 | 19 |  |  | 2011-07-15 | 2011-07-25 | 3d | 0d |  | intern [50%] | 12h |
| 21 | 1.1.3.5 | Print agenda |  | 1d | 2013-07-22 | 2013-07-24 | 20 |  |  | 2011-07-25 | 2011-07-27 | 1d | 0d |  | intern | 8h |
| 22 | 1.2 | Meeting occurs! | milestone | 1d | 2013-07-26 | 2013-07-29 | 2FS+2d, 17, 18, 19, 21 |  |  | 2011-07-29 | 2011-08-01 | 1d | 0d |  |  |  |

Notes:
- 22: A Must Start On constraint should be set for the day of the Meeting.
