# Office Remodel

Schedule from MS Project, 2013-06-03 to 2013-07-15, status date 2013-07-01, costs in $.
Workspace
DCF

## Calendars

- Standard: Mon-Fri 08:00-12:00, 13:00-17:00; Sat-Sun off.

## Schedule

| ID | WBS | Task | Type | Duration | Start | Finish | Predecessors | Baseline start | Baseline finish | Baseline duration | Total slack | Free slack | Constraint | Work | Cost | Baseline cost |
| --- | --- | --- | --- | --- | --- | --- | --- | --- | --- | --- | --- | --- | --- | --- | --- | --- |
| 1 | 1 | **Office Workspace Remodel** |  | 31d | 2013-06-03 | 2013-07-15 |  | 2013-06-03 | 2013-07-15 | 31d | 0d |  |  | 16h | 12,500 | 12,500 |
| 2 | 1.1 | **Space planning** |  | 11d | 2013-06-03 | 2013-06-17 |  | 2013-06-03 | 2013-06-17 | 11d | 0d |  |  |  |  |  |
| 3 | 1.1.1 | Interview space planners |  | 0.8w | 2013-06-03 | 2013-06-06 |  | 2013-06-03 | 2013-06-06 | 0.8w | 0d |  |  |  |  |  |
| 4 | 1.1.2 | Hire space planner |  | 1d | 2013-06-07 | 2013-06-07 | 3 | 2013-06-07 | 2013-06-07 | 1d | 0d |  |  |  |  |  |
| 5 | 1.1.3 | Meeting w/space planner |  | 3d | 2013-06-10 | 2013-06-12 | 4 | 2013-06-10 | 2013-06-12 | 3d | 0d |  |  |  |  |  |
| 6 | 1.1.4 | Finalize space plan |  | 3d | 2013-06-13 | 2013-06-17 | 5 | 2013-06-13 | 2013-06-17 | 3d | 0d |  |  |  |  |  |
| 7 | 1.1.5 | Space plan complete | milestone | 0d | 2013-06-17 | 2013-06-17 | 6 | 2013-06-17 | 2013-06-17 | 0d | 0d |  |  |  |  |  |
| 8 | 1.2 | **Furniture selection** |  | 13d | 2013-06-13 | 2013-07-02 |  | 2013-06-13 | 2013-07-02 | 13d | 10d |  |  | 16h |  |  |
| 9 | 1.2.1 | Preview furniture selections |  | 2.5d | 2013-06-13 | 2013-06-17 | 5 | 2013-06-13 | 2013-06-17 | 2.5d | 10d | 0d |  |  |  |  |
| 10 | 1.2.2 | Select new furniture |  | 2.5d | 2013-06-17 | 2013-06-19 | 9 | 2013-06-17 | 2013-06-19 | 2.5d | 10d | 0d |  | 16h |  |  |
| 11 | 1.2.3 | Order new furniture |  | 0.5d | 2013-06-20 | 2013-06-20 | 10 | 2013-06-20 | 2013-06-20 | 0.5d | 10d | 0d |  |  |  |  |
| 12 | 1.2.4 | Furniture delivered | milestone | 0d | 2013-07-02 | 2013-07-02 | 11FS+1.5w | 2013-07-02 | 2013-07-02 | 0d | 10d |  | start no earlier than 2013-07-02 |  |  |  |
| 13 | 1.3 | **Remodel workspace** |  | 15d | 2013-06-18 | 2013-07-08 |  | 2013-06-18 | 2013-07-08 | 15d | 0d |  |  |  | 12,500 | 12,500 |
| 14 | 1.3.1 | Hire contractor |  | 5d | 2013-06-18 | 2013-06-24 | 7 | 2013-06-18 | 2013-06-24 | 5d | 0d |  |  |  |  |  |
| 15 | 1.3.2 | Remodel workspace |  | 2w | 2013-06-25 | 2013-07-08 | 14 | 2013-06-25 | 2013-07-08 | 2w | 0d |  |  |  | 12,500 | 12,500 |
| 16 | 1.3.3 | Remodel complete | milestone | 0d | 2013-07-08 | 2013-07-08 | 15 | 2013-07-08 | 2013-07-08 | 0d | 5d |  |  |  |  |  |
| 17 | 1.4 | **New workspace** |  | 20d | 2013-06-18 | 2013-07-15 |  | 2013-06-18 | 2013-07-15 | 20d | 0d |  |  |  |  |  |
| 18 | 1.4.1 | Hire mover |  | 4d | 2013-06-18 | 2013-06-21 | 14SS | 2013-06-18 | 2013-06-21 | 4d | 8d | 1d |  |  |  |  |
| 19 | 1.4.2 | Pack workspace |  | 1d | 2013-06-25 | 2013-06-25 | 18, 14 | 2013-06-25 | 2013-06-25 | 1d | 7d | 0d |  |  |  |  |
| 20 | 1.4.3 | Move Equipment |  | 0.5d | 2013-06-25 | 2013-06-25 | 19FF | 2013-06-25 | 2013-06-25 | 0.5d | 7d |  |  |  |  |  |
| 21 | 1.4.4 | Remove existing furniture |  | 2d | 2013-07-05 | 2013-07-08 | 20 | 2013-07-05 | 2013-07-08 | 2d | 0d |  | as late as possible |  |  |  |
| 22 | 1.4.5 | Assemble new furniture |  | 2d | 2013-07-09 | 2013-07-10 | 21, 15 | 2013-07-09 | 2013-07-10 | 2d | 0d |  |  |  |  |  |
| 23 | 1.4.6 | Return equipment |  | 0.5d | 2013-07-10 | 2013-07-10 | 22FS-0.5d | 2013-07-10 | 2013-07-10 | 0.5d | 0d |  |  |  |  |  |
| 24 | 1.4.7 | Unpack workspace |  | 1d | 2013-07-11 | 2013-07-11 | 23 | 2013-07-11 | 2013-07-11 | 1d | 0d |  |  |  |  |  |
| 25 | 1.4.8 | Workspace final clean |  | 2d | 2013-07-12 | 2013-07-15 | 24 | 2013-07-12 | 2013-07-15 | 2d | 0d |  |  |  |  |  |
| 26 | 1.5 | Workspace remodel complete | milestone | 0d | 2013-07-15 | 2013-07-15 | 17 | 2013-07-15 | 2013-07-15 | 0d | 0d |  | finish no later than 2013-07-17 |  |  |  |

Notes:
- 11: Allow 1.5 weeks for delivery.
