# 2008 Annual Report

Schedule from MS Project, 2013-01-04 to 2013-02-28, status date 2013-02-28, costs in $, A marks actual dates.
DCF
The CFO must review all materials before finalizing the report.

## Calendars

- Standard: Mon-Fri 07:00-11:00, 12:00-16:00; Sat-Sun off.

## Resources

| Resource | Group | Rate |
| --- | --- | --- |
| Office Temp | office staff | 12 |
| Editor |  | 30 |
| Office Manager | management | 21.63 |
| Vice President | management | 36.06 |
| Administrative Assistant |  | 20 |
| President | management | 43.27 |
| Chief Financial Officer | management | 38.46 |
| Accounting Assistant | office staff | 15 |
| Accountant | office staff | 40 |
| Layout Coordinator |  | 25 |
| Marketing Vice President | management | 33.65 |

## Schedule

| ID | WBS | Task | Type | Duration | Start | Finish | Predecessors | Complete | Remaining | Baseline start | Baseline finish | Baseline duration | Total slack | Constraint | Resources | Work | Actual work | Cost | Baseline cost | Actual cost |
| --- | --- | --- | --- | --- | --- | --- | --- | --- | --- | --- | --- | --- | --- | --- | --- | --- | --- | --- | --- | --- |
| 1 | 1 | **Annual Financial Report** |  | 39.38d | 2013-01-04 A | 2013-02-28 |  | 44% | 22.2d | 2011-01-07 | 2011-03-03 | 39.38d | 0d |  |  | 634h | 302h | 16,440.92 | 16,440.92 | 8,108.46 |
| 2 | 1.1 | **Initial Planning** |  | 3d | 2013-01-04 A | 2013-01-08 A |  | 100% |  | 2011-01-07 | 2011-01-11 | 3d |  |  |  | 72h | 72h | 1,719.23 | 1,719.23 | 1,719.23 |
| 3 | 1.1.1 | Outline report articles |  | 3d | 2013-01-04 A | 2013-01-08 A |  | 100% |  | 2011-01-07 | 2011-01-11 | 3d |  |  | Office Manager; Administrative Assistant; Editor | 72h | 72h | 1,719.23 | 1,719.23 | 1,719.23 |
| 4 | 1.2 | **Interview Management** |  | 3.5d | 2013-01-07 A | 2013-01-10 A |  | 100% |  | 2011-01-10 | 2011-01-13 | 3.5d |  |  |  | 32h | 32h | 1,085.77 | 1,085.77 | 1,085.77 |
| 5 | 1.2.1 | President |  | 0.5d | 2013-01-07 A | 2013-01-07 A | 3 | 100% |  | 2011-01-10 | 2011-01-10 | 0.5d |  |  | Editor; President | 8h | 8h | 293.08 | 293.08 | 293.08 |
| 6 | 1.2.2 | Vice President |  | 0.5d | 2013-01-07 A | 2013-01-07 A | 5 | 100% |  | 2011-01-10 | 2011-01-10 | 0.5d |  |  | Editor; Vice President | 8h | 8h | 264.23 | 264.23 | 264.23 |
| 7 | 1.2.3 | Marketing VP |  | 0.5d | 2013-01-10 A | 2013-01-10 A | 6 | 100% |  | 2011-01-13 | 2011-01-13 | 0.5d |  |  | Editor; Marketing Vice President | 8h | 8h | 254.62 | 254.62 | 254.62 |
| 8 | 1.2.4 | Chief Financial Officer |  | 0.5d | 2013-01-08 A | 2013-01-08 A | 7 | 100% |  | 2011-01-11 | 2011-01-11 | 0.5d |  |  | Editor; Chief Financial Officer | 8h | 8h | 273.85 | 273.85 | 273.85 |
| 9 | 1.3 | **Assemble Financial Reports** |  | 13d | 2013-01-07 A | 2013-01-24 |  | 94% | 0.79d | 2011-01-10 | 2011-01-27 | 13d | 25.38d |  |  | 206h | 198h | 5,783.46 | 5,783.46 | 5,303.46 |
| 10 | 1.3.1 | Gather financial data |  | 3.38d | 2013-01-07 A | 2013-01-10 A | 3 | 100% |  | 2011-01-10 | 2011-01-13 | 3.38d |  |  | Administrative Assistant [200%]; Accounting Assistant; Accountant | 63h | 63h | 1,665 | 1,665 | 1,665 |
| 11 | 1.3.2 | Format reports |  | 2d | 2013-01-08 A | 2013-01-09 A | 10FS-2d | 100% |  | 2011-01-11 | 2011-01-12 | 2d |  |  | Editor; Layout Coordinator | 32h | 32h | 880 | 880 | 880 |
| 12 | 1.3.3 | Compile data reference report |  | 1d | 2013-01-14 A | 2013-01-14 A | 11 | 100% |  | 2011-01-17 | 2011-01-17 | 1d |  |  | Administrative Assistant | 8h | 8h | 160 | 160 | 160 |
| 13 | 1.3.4 | Create graphics and charts |  | 3.12d | 2013-01-14 A | 2013-01-16 A | 12SS | 100% |  | 2011-01-17 | 2011-01-19 | 3.12d |  |  | Editor; Office Temp; Layout Coordinator | 47h | 47h | 1,060 | 1,060 | 1,060 |
| 14 | 1.3.5 | Review by CFO |  | 5d | 2013-01-14 A | 2013-01-18 A | 13 | 100% |  | 2011-01-17 | 2011-01-21 | 5d |  |  | Chief Financial Officer | 40h | 40h | 1,538.46 | 1,538.46 | 1,538.46 |
| 15 | 1.3.6 | Edit |  | 2d | 2013-01-21 A | 2013-01-22 | 14 | 50% | 1d | 2011-01-24 | 2011-01-25 | 2d | 26.38d |  | Editor | 16h | 8h | 480 | 480 |  |
| 16 | 1.3.7 | Final approval | milestone | 0d | 2013-01-24 | 2013-01-24 |  |  |  | 2011-01-27 | 2011-01-27 | 0d | 0d | start no earlier than 2013-01-24 |  |  |  |  |  |  |
| 17 | 1.4 | **Write Articles** |  | 10d | 2013-01-24 | 2013-02-06 |  |  |  | 2011-01-27 | 2011-02-09 | 10d | 0d |  |  | 152h |  | 4,170.77 | 4,170.77 |  |
| 18 | 1.4.1 | Write first draft |  | 3d | 2013-01-24 | 2013-01-28 | 16 |  |  | 2011-01-27 | 2011-01-31 | 3d | 0d |  | Editor; Office Manager | 48h |  | 1,239.23 | 1,239.23 |  |
| 19 | 1.4.2 | Management review |  | 5d | 2013-01-29 | 2013-02-04 | 18 |  |  | 2011-02-01 | 2011-02-07 | 5d | 0d | as late as possible | Office Manager; Marketing Vice President | 80h |  | 2,211.54 | 2,211.54 |  |
| 20 | 1.4.3 | Edit |  | 3d | 2013-02-04 | 2013-02-06 | 19FS-1d |  |  | 2011-02-07 | 2011-02-09 | 3d | 0d |  | Editor | 24h |  | 720 | 720 |  |
| 21 | 1.4.4 | Final text approval | milestone | 0d | 2013-02-06 | 2013-02-06 | 20 |  |  | 2011-02-09 | 2011-02-09 | 0d | 0d |  |  |  |  |  |  |  |
| 22 | 1.5 | **Prepare Final Materials** |  | 8.5d | 2013-02-07 | 2013-02-19 |  |  |  | 2011-02-10 | 2011-02-22 | 8.5d | 0d |  |  | 132h |  | 3,137.69 | 3,137.69 |  |
| 23 | 1.5.1 | Final layout |  | 3d | 2013-02-07 | 2013-02-11 | 21 |  |  | 2011-02-10 | 2011-02-14 | 3d | 0d |  | Administrative Assistant; Layout Coordinator | 48h |  | 1,080 | 1,080 |  |
| 24 | 1.5.2 | Final proof |  | 3d | 2013-02-12 | 2013-02-14 | 23 |  |  | 2011-02-15 | 2011-02-17 | 3d | 0d |  | Office Manager; Layout Coordinator | 48h |  | 1,119.23 | 1,119.23 |  |
| 25 | 1.5.3 | Copy reports |  | 2.5d | 2013-02-15 | 2013-02-19 | 24 |  |  | 2011-02-18 | 2011-02-22 | 2.5d | 0d |  | Administrative Assistant | 20h |  | 400 | 400 |  |
| 26 | 1.5.4 | Write cover letter |  | 2d | 2013-02-15 | 2013-02-19 | 25FF |  |  | 2011-02-18 | 2011-02-22 | 2d | 0d |  | Marketing Vice President | 16h |  | 538.46 | 538.46 |  |

Notes:
- 13: Due to server problems there was a 1 day delay in work on graphics and charts.

| ID | WBS | Task | Type | Duration | Start | Finish | Predecessors | Baseline start | Baseline finish | Baseline duration | Total slack | Constraint | Resources | Work | Cost | Baseline cost |
| --- | --- | --- | --- | --- | --- | --- | --- | --- | --- | --- | --- | --- | --- | --- | --- | --- |
| 27 | 1.6 | **Distribute Reports** |  | 6.88d | 2013-02-19 | 2013-02-28 |  | 2011-02-22 | 2011-03-03 | 6.88d | 0d |  |  | 40h | 544 | 544 |
| 28 | 1.6.1 | Order envelopes/paper stock |  | 1d | 2013-02-19 | 2013-02-20 | 26 | 2011-02-22 | 2011-02-23 | 1d | 0d |  | Administrative Assistant | 8h | 160 | 160 |
| 29 | 1.6.2 | Print cover letters/envelopes |  | 2d | 2013-02-25 | 2013-02-27 | 28FS+3d | 2011-02-28 | 2011-03-02 | 2d | 0d |  | Office Temp | 16h | 192 | 192 |
| 30 | 1.6.3 | Stuff report packets |  | 1d | 2013-02-27 | 2013-02-28 | 29 | 2011-03-02 | 2011-03-03 | 1d | 0d |  | Office Temp [200%] | 16h | 192 | 192 |
| 31 | 1.6.4 | Report packets sent | milestone | 0d | 2013-02-28 | 2013-02-28 | 30 | 2011-03-03 | 2011-03-03 | 0d | 0d | as late as possible |  |  |  |  |
