# 2008 Annual Report

Schedule from MS Project, 2013-01-04 to 2013-08-01, status date 2013-02-28, costs in $, A marks actual dates.
DCF
The CFO must review all materials before finalizing the report.

## Calendars

- Standard: Mon-Fri 07:00-11:00, 12:00-16:00; Sat-Sun off.

## Resources

| Resource | Group | Rate |
| --- | --- | --- |
| Office Temp | office staff | 12 |
| Editor |  | 30 |
| Office Manager | management | 21.63 |
| Vice President | management | 36.06 |
| Administrative Assistant |  | 20 |
| President | management | 43.27 |
| Chief Financial Officer | management | 38.46 |
| Accounting Assistant | office staff | 15 |
| Accountant | office staff | 40 |
| Layout Coordinator |  | 25 |
| Marketing Vice President | management | 33.65 |

## Schedule

| ID | WBS | Task | Type | Duration | Start | Finish | Predecessors | Complete | Remaining | Baseline start | Baseline finish | Baseline duration | Total slack | Constraint | Resources | Work | Actual work | Cost | Baseline cost | Actual cost |
| --- | --- | --- | --- | --- | --- | --- | --- | --- | --- | --- | --- | --- | --- | --- | --- | --- | --- | --- | --- | --- |
| 1 | A | **Annual Financial Report** |  | 150d | 2013-01-04 A | 2013-08-01 |  | 33% | 99.83d | 2013-01-04 | 2013-08-01 | 150d | 0d |  |  | 1207h | 358h | 16,847.23 | 16,847.23 | 9,827.69 |
| 2 | A-001 | **Initial Planning** |  | 3d | 2013-01-04 A | 2013-01-08 A |  | 100% |  | 2013-01-04 | 2013-01-08 | 3d |  |  |  | 72h | 72h | 1,719.23 | 1,719.23 | 1,719.23 |
| 3 | A-001.a | Outline report articles |  | 3d | 2013-01-04 A | 2013-01-08 A |  | 100% |  | 2013-01-04 | 2013-01-08 | 3d |  |  | Office Manager; Administrative Assistant; Editor | 72h | 72h | 1,719.23 | 1,719.23 | 1,719.23 |
| 4 | A-002 | **Interview Management** |  | 3.5d | 2013-01-07 A | 2013-01-10 A |  | 100% |  | 2013-01-07 | 2013-01-10 | 3.5d |  |  |  | 32h | 32h | 1,085.77 | 1,085.77 | 1,085.77 |
| 5 | A-002.a | President |  | 0.5d | 2013-01-07 A | 2013-01-07 A | 3 | 100% |  | 2013-01-07 | 2013-01-07 | 0.5d |  |  | Editor; President | 8h | 8h | 293.08 | 293.08 | 293.08 |
| 6 | A-002.b | Vice President |  | 0.5d | 2013-01-07 A | 2013-01-07 A | 5 | 100% |  | 2013-01-07 | 2013-01-07 | 0.5d |  |  | Editor; Vice President | 8h | 8h | 264.23 | 264.23 | 264.23 |
| 7 | A-002.c | Marketing VP |  | 0.5d | 2013-01-10 A | 2013-01-10 A | 6 | 100% |  | 2013-01-10 | 2013-01-10 | 0.5d |  |  | Editor; Marketing Vice President | 8h | 8h | 254.62 | 254.62 | 254.62 |
| 8 | A-002.d | Chief Financial Officer |  | 0.5d | 2013-01-08 A | 2013-01-08 A | 7 | 100% |  | 2013-01-08 | 2013-01-08 | 0.5d |  |  | Editor; Chief Financial Officer | 8h | 8h | 273.85 | 273.85 | 273.85 |
| 9 | A-003 | **Assemble Financial Reports** |  | 13d | 2013-01-07 A | 2013-01-24 A |  | 100% |  | 2013-01-07 | 2013-01-24 | 13d |  |  |  | 206h | 206h | 5,783.46 | 5,783.46 | 5,783.46 |
| 10 | A-003.a | Gather financial data |  | 3.38d | 2013-01-07 A | 2013-01-10 A | 3 | 100% |  | 2013-01-07 | 2013-01-10 | 3.38d |  |  | Administrative Assistant [200%]; Accounting Assistant; Accountant | 63h | 63h | 1,665 | 1,665 | 1,665 |
| 11 | A-003.b | Format reports |  | 2d | 2013-01-08 A | 2013-01-09 A | 10FS-2d | 100% |  | 2013-01-08 | 2013-01-09 | 2d |  |  | Editor; Layout Coordinator | 32h | 32h | 880 | 880 | 880 |
| 12 | A-003.c | Compile data reference report |  | 1d | 2013-01-14 A | 2013-01-14 A | 11 | 100% |  | 2013-01-14 | 2013-01-14 | 1d |  |  | Administrative Assistant | 8h | 8h | 160 | 160 | 160 |
| 13 | A-003.d | Create graphics and charts |  | 3.12d | 2013-01-14 A | 2013-01-16 A | 12SS | 100% |  | 2013-01-14 | 2013-01-16 | 3.12d |  |  | Editor; Office Temp; Layout Coordinator | 47h | 47h | 1,060 | 1,060 | 1,060 |
| 14 | A-003.e | Review by CFO |  | 5d | 2013-01-14 A | 2013-01-18 A | 13 | 100% |  | 2013-01-14 | 2013-01-18 | 5d |  |  | Chief Financial Officer | 40h | 40h | 1,538.46 | 1,538.46 | 1,538.46 |
| 15 | A-003.f | Edit |  | 2d | 2013-01-21 A | 2013-01-22 A | 14 | 100% |  | 2013-01-21 | 2013-01-22 | 2d |  |  | Editor | 16h | 16h | 480 | 480 | 480 |
| 16 | A-003.g | Final approval | milestone | 0d | 2013-01-24 A | 2013-01-24 A |  | 100% |  | 2013-01-24 | 2013-01-24 | 0d |  | start no earlier than 2013-01-24 |  |  |  |  |  |  |
| 17 | A-004 | **Write Articles** |  | 121d | 2013-01-24 A | 2013-07-11 |  | 25% | 90.75d | 2013-01-24 | 2013-07-11 | 121d | 0d |  |  | 168h | 48h | 4,613.08 | 4,613.08 | 1,239.23 |
| 18 | A-004.a | Write first draft |  | 3d | 2013-01-24 A | 2013-01-28 A | 16 | 100% |  | 2013-01-24 | 2013-01-28 | 3d |  |  | Editor; Office Manager | 48h | 48h | 1,239.23 | 1,239.23 | 1,239.23 |
| 19 | A-004.b | Management review |  | 6d | 2013-07-02 | 2013-07-09 | 18 |  |  | 2013-07-02 | 2013-07-09 | 6d | 0d | finish no earlier than 2013-07-09 | Office Manager; Marketing Vice President | 96h |  | 2,653.85 | 2,653.85 |  |
| 20 | A-004.c | Edit |  | 3d | 2013-07-09 | 2013-07-11 | 19FS-1d |  |  | 2013-07-09 | 2013-07-11 | 3d | 0d |  | Editor | 24h |  | 720 | 720 |  |
| 21 | A-004.d | Final text approval | milestone | 0d | 2013-07-11 | 2013-07-11 | 20 |  |  | 2013-07-11 | 2013-07-11 | 0d | 0d |  |  |  |  |  |  |  |
| 22 | A-005 | **Prepare Final Materials** |  | 8.5d | 2013-07-12 | 2013-07-24 |  |  |  | 2013-07-12 | 2013-07-24 | 8.5d | 0d |  |  | 132h |  | 3,137.69 | 3,137.69 |  |
| 23 | A-005.a | Final layout |  | 3d | 2013-07-12 | 2013-07-16 | 21 |  |  | 2013-07-12 | 2013-07-16 | 3d | 0d |  | Administrative Assistant; Layout Coordinator | 48h |  | 1,080 | 1,080 |  |
| 24 | A-005.b | Final proof |  | 3d | 2013-07-17 | 2013-07-19 | 23 |  |  | 2013-07-17 | 2013-07-19 | 3d | 0d |  | Office Manager; Layout Coordinator | 48h |  | 1,119.23 | 1,119.23 |  |
| 25 | A-005.c | Copy reports |  | 2.5d | 2013-07-22 | 2013-07-24 | 24 |  |  | 2013-07-22 | 2013-07-24 | 2.5d | 0d |  | Administrative Assistant | 20h |  | 400 | 400 |  |
| 26 | A-005.d | Write cover letter |  | 2d | 2013-07-22 | 2013-07-24 | 25FF |  |  | 2013-07-22 | 2013-07-24 | 2d | 0d |  | Marketing Vice President | 16h |  | 538.46 | 538.46 |  |

Notes:
- 13: Due to server problems there was a 1 day delay in work on graphics and charts.

| ID | WBS | Task | Type | Duration | Start | Finish | Predecessors | Baseline start | Baseline finish | Baseline duration | Total slack | Resources | Work | Cost | Baseline cost |
| --- | --- | --- | --- | --- | --- | --- | --- | --- | --- | --- | --- | --- | --- | --- | --- |
| 27 | A-006 | **Distribute Reports** |  | 149.88d | 2013-01-04 | 2013-08-01 |  | 2013-01-04 | 2013-08-01 | 149.88d | 0d |  | 597h | 508 | 508 |
| 28 | A-006.a | Order envelopes/paper stock |  | 1d | 2013-07-24 | 2013-07-25 | 26 | 2013-07-24 | 2013-07-25 | 1d | 0d | Administrative Assistant | 8h | 160 | 160 |
| 29 | A-006.b | Print cover letters/envelopes |  | 1.62d | 2013-07-30 | 2013-07-31 | 28FS+3d | 2013-07-30 | 2013-07-31 | 1.62d | 0d | Office Temp | 13h | 156 | 156 |
| 30 | A-006.c | Stuff report packets |  | 1d | 2013-08-01 | 2013-08-01 | 29 | 2013-08-01 | 2013-08-01 | 1d | 0d | Office Temp [200%] | 16h | 192 | 192 |
| 31 | A-006.d | Report packets sent | milestone | 0d | 2013-08-01 | 2013-08-01 | 30 | 2013-08-01 | 2013-08-01 | 0d | 0d |  |  |  |  |
| 32 | 1.6.5 | Company Conference |  | 25.62d | 2013-01-04 | 2013-02-08 |  | 2013-01-04 | 2013-02-08 | 25.62d | 124.25d |  | 560h |  |  |
